# Biogen Idec Timelines

Schedule from MS Project, 2012-10-04 to 2015-03-03, A marks actual dates.

## Calendars

- Standard: Mon-Fri 09:00-13:00, 14:00-18:00; Sat-Sun off. Exceptions (off unless hours are given): 2013-11-02 09:00-13:00, 14:00-18:00, 2013-11-17 09:00-13:00, 14:00-18:00, 2013-11-30 09:00-13:00, 14:00-18:00.

## Resources

| Resource |
| --- |
| 62 |
| 61 |
| 63 |
| 64 |

## Schedule

| ID | WBS | Task | Type | Duration | Start | Finish | Predecessors | Complete | Remaining | Total slack | Free slack | Constraint |
| --- | --- | --- | --- | --- | --- | --- | --- | --- | --- | --- | --- | --- |
| 1 | 1 | TT Agreement | milestone | 0d | 2012-10-04 | 2012-10-04 |  |  |  | 632d |  | start no earlier than 2012-10-04 |
| 2 | 2 | Technical Team set up |  | 0.2w? | 2012-10-04 | 2012-10-04 | 1 |  |  | 631d |  |  |
| 3 | 3 | Technical Meeting in RU | milestone | 0d | 2012-11-13 A | 2012-11-13 A | 2 | 100% |  |  |  | start no earlier than 2012-11-13 |
| 4 | 4 | Communication Plan set up | milestone | 0w | 2012-12-05 A | 2012-12-05 A | 3 | 100% |  |  |  | start no earlier than 2012-12-05 |
| 5 | 5 | II KO Meeting |  | 2d | 2013-03-20 A | 2013-03-21 A | 4 | 100% |  |  |  | start no earlier than 2013-03-20 |
| 6 | 6 | RU Process Flow confirmation and Ancillary equipment technical features definition |  | 1w | 2013-03-25 A | 2013-03-29 A | 5 | 100% |  |  |  | finish no earlier than 2013-03-29 |
| 7 | 7 | Sending Unit Product TT Pack sharing |  | 5d | 2013-06-05 A | 2013-06-11 A | 1 | 100% |  |  |  | start no earlier than 2013-06-05 |
| 8 | 8 | **Main documents** |  | 391d? | 2012-10-25 A | 2014-04-21 |  | 41% | 232.48d? | 69d |  |  |
| 9 | 8.1 | **Transfer Technology** |  | 258d? | 2012-10-25 A | 2013-10-21 |  | 78% | 57.17d? | 53d |  |  |
| 10 | 8.1.1 | **Gap Analyses** |  | 4d? | 2012-10-25 | 2012-10-30 |  |  |  | 282.7d |  |  |
| 11 | 8.1.1.1 | FMEA and Gaps analyses Document editing |  | 1d? | 2012-10-25 | 2012-10-25 |  |  |  | 282.7d | 0d |  |
| 12 | 8.1.1.2 | draft sharing |  | 0.2w? | 2012-10-26 | 2012-10-26 | 11 |  |  | 282.7d | 0d |  |
| 13 | 8.1.1.3 | Document review and updating |  | 0.2w? | 2012-10-29 | 2012-10-29 | 12 |  |  | 282.7d | 0d |  |
| 14 | 8.1.1.4 | approval |  | 0.2w? | 2012-10-30 | 2012-10-30 | 13 |  |  | 282.7d | 33d |  |
| 15 | 8.1.2 | **TTP** |  | 94d | 2013-06-12 A | 2013-10-21 |  | 82% | 17.35d | 53d |  |  |
| 16 | 8.1.2.1 | FMEA and Gaps analyses Document editing |  | 10d | 2013-06-12 A | 2013-06-25 A | 14 | 100% |  |  |  |  |
| 17 | 8.1.2.2 | draft sharing | milestone | 0d | 2013-07-15 A | 2013-07-15 A | 16 | 100% |  |  |  | start no earlier than 2013-06-03 |
| 18 | 8.1.2.3 | Document review and updating |  | 8d | 2013-07-19 A | 2013-07-30 A | 17 | 100% |  |  |  | finish no earlier than 2013-07-30 |
| 19 | 8.1.2.4 | approval |  | 41d | 2013-08-02 A | 2013-09-27 A | 18, 78, 80, 82 | 100% |  |  |  | finish no earlier than 2013-09-27 |
| 20 | 8.1.2.5 | **Tech Run protocol** |  | 14d | 2013-09-20 A | 2013-10-09 |  | 68% | 4.5d | 25d |  |  |
| 21 | 8.1.2.5.1 | Document editing |  | 6d | 2013-09-20 A | 2013-09-27 A | 18 | 100% |  |  |  | start no earlier than 2013-09-20 |
| 22 | 8.1.2.5.2 | draft sharing | milestone | 0d | 2013-09-27 A | 2013-09-27 A | 21 | 100% |  |  |  |  |
| 23 | 8.1.2.5.3 | Document review and updating |  | 7d | 2013-09-30 A | 2013-10-08 | 22 | 50% | 3.5d | 25d | 0d |  |
| 24 | 8.1.2.5.4 | approval |  | 1d | 2013-10-09 | 2013-10-09 | 23 |  |  | 25d | 0d |  |

| ID | WBS | Task | Type | Duration | Start | Finish | Predecessors | Complete | Total slack | Free slack | Constraint |
| --- | --- | --- | --- | --- | --- | --- | --- | --- | --- | --- | --- |
| 25 | 8.1.2.6 | **Tech Run MBR** |  | 11d | 2013-10-04 | 2013-10-21 |  |  | 53d | 10d |  |
| 26 | 8.1.2.6.1 | draft sharing | milestone | 0w | 2013-10-04 | 2013-10-04 | 22FS+5d |  | 53d | 0d |  |
| 27 | 8.1.2.6.2 | Document review and updating |  | 10d | 2013-10-07 | 2013-10-18 | 26 |  | 53d | 0d |  |
| 28 | 8.1.2.6.3 | approval |  | 1d | 2013-10-21 | 2013-10-21 | 27 |  | 53d |  |  |
| 29 | 8.2 | **Validation** |  | 14d | 2013-07-19 A | 2013-08-07 A |  | 100% |  |  |  |
| 30 | 8.2.1 | **VMP** |  | 9d | 2013-07-19 A | 2013-07-31 A |  | 100% |  |  |  |
| 31 | 8.2.1.1 | draft sharing (receiving unit) | milestone | 0d | 2013-07-19 A | 2013-07-19 A |  | 100% |  |  |  |
| 32 | 8.2.1.2 | Document review and updating (sending unit/receiving unit) |  | 8d | 2013-07-22 A | 2013-07-31 A | 31 | 100% |  |  |  |
| 33 | 8.2.1.3 | approval (sending unit/receiving unit) | milestone | 0d | 2013-07-31 A | 2013-07-31 A | 32 | 100% |  |  |  |
| 34 | 8.2.2 | **Equipment validation protocol (receiving unit internal management)** |  | 5d | 2013-08-01 A | 2013-08-07 A | 33 | 100% |  |  |  |
| 35 | 8.2.2.1 | approvals |  | 5d | 2013-08-01 A | 2013-08-07 A |  | 100% |  |  | start no earlier than 2013-07-25 |
| 36 | 8.3 | **Process Validation** |  | 141d | 2013-10-10 | 2014-04-21 |  |  | 25d |  |  |
| 37 | 8.3.1 | **Master Batch Record Approval** |  | 141d | 2013-10-10 | 2014-04-21 |  |  | 25d |  |  |
| 38 | 8.3.1.1 | **PV** |  | 65d | 2014-01-21 | 2014-04-21 |  |  | 0d |  |  |
| 39 | 8.3.1.1.1 | MBR concentration 3 PV |  | 20d | 2014-01-21 | 2014-02-17 | 48SS+7d |  | 0d |  |  |
| 40 | 8.3.1.1.2 | MBR concentration 1 PV |  | 15d | 2014-02-18 | 2014-03-10 | 39 |  | 69d | 0d |  |
| 41 | 8.3.1.1.3 | MBR concentration 2 PV |  | 10d | 2014-03-11 | 2014-03-24 | 40 |  | 69d | 0d |  |
| 42 | 8.3.1.1.4 | MBR concentration 4 PV |  | 10d | 2014-03-25 | 2014-04-07 | 41 |  | 69d | 0d |  |
| 43 | 8.3.1.1.5 | MBR concentration 5 PV |  | 10d | 2014-04-08 | 2014-04-21 | 42 |  | 69d | 11d |  |
| 44 | 8.3.1.2 | **Tech Runs** |  | 35d | 2013-10-10 | 2013-11-25 |  |  | 25d |  |  |
| 45 | 8.3.1.2.1 | MBR tech Run 1 issuing and approval |  | 14d | 2013-10-10 | 2013-10-29 | 24 |  | 25d | 4d |  |
| 46 | 8.3.1.2.2 | MBR tech Run 2 issuing and approval |  | 14d | 2013-11-07 | 2013-11-25 | 24 |  | 4d |  | start no earlier than 2013-11-07 |
| 47 | 8.3.1.2.3 | MBR tech Run 3 issuing and approval |  | 14d | 2013-11-07 | 2013-11-25 | 24 |  | 26d | 7d | start no earlier than 2013-11-07 |
| 48 | 8.3.2 | Process Validation Protocol approval |  | 3w | 2014-01-10 | 2014-01-30 | 163 |  | 0d |  |  |

| ID | WBS | Task | Type | Duration | Start | Finish | Predecessors | Complete | Remaining | Total slack | Free slack | Constraint |
| --- | --- | --- | --- | --- | --- | --- | --- | --- | --- | --- | --- | --- |
| 49 | 8.4 | **Raw materials Documentation** |  | 12d | 2013-09-27 A | 2013-10-14 |  | 93% | 0.85d | 55d |  |  |
| 50 | 8.4.1 | Information sharing | milestone | 0w | 2013-09-27 A | 2013-09-27 A |  | 100% |  |  |  | start no earlier than 2013-09-27 |
| 51 | 8.4.2 | Evaluation of info and gaps identification |  | 5d | 2013-09-27 A | 2013-10-03 A | 50 | 100% |  |  |  |  |
| 52 | 8.4.3 | **Specification** |  | 12d | 2013-09-27 A | 2013-10-14 | 50 | 90% | 1.2d | 55d | 11d |  |
| 53 | 8.4.3.1 | Raw Materials specification approval |  | 12d | 2013-09-27 A | 2013-10-14 |  | 90% | 1.2d | 55d | 4d |  |
| 54 | 9 | **Equipment** |  | 265d | 2012-10-15 A | 2013-10-18 |  | 99% | 3.25d | 54d | 11d |  |
| 55 | 9.1 | Tanks Urs definition and technical discussion with the Supplier |  | 14.2w | 2012-12-12 A | 2013-03-20 A | 14 | 100% |  |  |  | finish no earlier than 2013-03-20 |
| 56 | 9.2 | Tanks Urs finalization, Orders and Delivey |  | 22w | 2013-03-04 A | 2013-08-02 A | 55, 14 | 100% |  |  |  | finish no earlier than 2013-08-02 |
| 57 | 9.3 | Transfer Line Order and Delivey |  | 8w | 2013-02-14 A | 2013-04-10 A | 14 | 100% |  |  |  | finish no earlier than 2012-12-14 |
| 58 | 9.4 | Freezer order and delivery |  | 81d | 2013-03-04 A | 2013-06-24 A | 14 | 100% |  |  |  | finish no earlier than 2013-06-24 |
| 59 | 9.5 | Water Bath order and delivery |  | 10.8w | 2013-03-04 A | 2013-05-16 A | 14 | 100% |  |  |  | finish no earlier than 2013-05-31 |
| 60 | 9.6 | **Filling Machine** |  | 181d | 2012-10-15 A | 2013-06-24 A | 14 | 100% |  |  |  |  |
| 61 | 9.6.1 | Urs finalization - quotation negotiation with the supplier |  | 3w | 2012-10-15 A | 2012-11-02 A |  | 100% |  |  |  | start no earlier than 2012-10-15 |
| 62 | 9.6.2 | Client Approval of the Filling trolley main technical features |  | 2d | 2012-11-13 A | 2012-11-14 A | 3 | 100% |  |  |  |  |
| 63 | 9.6.3 | Filling machine formats |  | 28.4w | 2012-11-15 A | 2013-05-31 A | 62 | 100% |  |  |  | finish no earlier than 2013-05-31 |
| 64 | 9.6.4 | Filling machine stoppers hopper |  | 31.6w | 2012-11-15 A | 2013-06-24 A | 62 | 100% |  |  |  | finish no earlier than 2013-06-24 |
| 65 | 9.6.5 | Filling machine peristaltic pump trolley FAT |  | 0.4w | 2013-05-22 A | 2013-05-23 A | 62 | 100% |  |  |  | finish no earlier than 2013-05-23 |
| 66 | 9.7 | **Installation & Validation** |  | 220d | 2012-12-17 A | 2013-10-18 | 14 | 93% | 15.6d | 54d |  |  |
| 67 | 9.7.1 | Transfer line installation & validation |  | 6w | 2012-12-17 A | 2013-09-13 A | 57, 56FS+3w | 100% |  |  |  |  |
| 68 | 9.7.2 | Tank installation & validation |  | 3w | 2013-08-19 A | 2013-09-06 A | 56FS+2w | 100% |  |  |  | start no earlier than 2013-08-01 |
| 69 | 9.7.3 | Peristaltic pump installation |  | 2w | 2013-08-02 A | 2013-08-15 A |  | 100% |  |  |  | start no earlier than 2013-08-02 |
| 70 | 9.7.4 | Filling system and contact parts installation & validation (assumed done without shut-down; to be confirmed) |  | 3w | 2013-08-02 A | 2013-08-22 A | 60, 85, 92, 89 | 100% |  |  |  | start no earlier than 2013-08-02 |
| 71 | 9.7.5 | Washing - Tunnel - Crimping - Autoclave |  | 3w | 2013-08-02 A | 2013-08-22 A | 63, 64, 65, 85, 92, 89 | 100% |  |  |  | start no earlier than 2013-08-02 |
| 72 | 9.7.6 | Trial Crimping |  | 1w | 2013-09-02 A | 2013-09-06 A |  | 100% |  |  |  | start no earlier than 2013-09-02 |
| 73 | 9.7.7 | Placebo bottles for the water bath qualifications | milestone | 0w | 2013-10-04 A | 2013-10-04 A |  | 100% |  |  |  | finish no earlier than 2013-10-04 |
| 74 | 9.7.8 | Waterbath installation and qualification |  | 10d | 2013-10-07 | 2013-10-18 | 73 |  |  | 54d |  |  |
| 75 | 9.7.9 | Freezer installation and qualification |  | 8.2w | 2013-08-02 A | 2013-09-27 A | 58, 59 | 100% |  |  |  | finish no earlier than 2013-09-27 |

| ID | WBS | Task | Type | Duration | Start | Finish | Predecessors | Complete | Remaining | Total slack | Free slack | Constraint |
| --- | --- | --- | --- | --- | --- | --- | --- | --- | --- | --- | --- | --- |
| 76 | 10 | **Packaging components** |  | 30.2w | 2013-02-25 A | 2013-09-23 | 14 | 97% | 0.94w | 63d |  |  |
| 77 | 10.1 | **Specs** |  | 37d | 2013-08-02 A | 2013-09-23 |  | 67% | 12.33d | 63d | 30d |  |
| 78 | 10.1.1 | stopper specs draft shared | milestone | 0w | 2013-08-02 A | 2013-08-02 A |  | 100% |  |  |  |  |
| 79 | 10.1.2 | stopper specs approved |  | 1w | 2013-09-17 A | 2013-09-23 | 78 | 50% | 0.5w | 63d | 0d | finish no earlier than 2013-09-23 |
| 80 | 10.1.3 | seal draft specs shared | milestone | 0w | 2013-08-02 A | 2013-08-02 A |  | 100% |  |  |  |  |
| 81 | 10.1.4 | seal draft specs approved |  | 1w | 2013-09-17 A | 2013-09-23 A | 80 | 100% |  |  |  | finish no earlier than 2013-09-23 |
| 82 | 10.1.5 | vial draft specs shared | milestone | 0w | 2013-08-02 A | 2013-08-02 A |  | 100% |  |  |  |  |
| 83 | 10.1.6 | vial draft specs approved |  | 1w | 2013-09-17 A | 2013-09-23 | 82 | 50% | 0.5w | 63d | 0d | finish no earlier than 2013-09-23 |
| 84 | 10.2 | **Stoppers** |  | 65d | 2013-04-26 A | 2013-07-25 A |  | 100% |  |  |  |  |
| 85 | 10.2.1 | new code 272060 definition and confirmation | milestone | 0w | 2013-04-26 A | 2013-04-26 A |  | 100% |  |  |  | start no earlier than 2013-04-26 |
| 86 | 10.2.2 | 250.000 pz delivery |  | 13w | 2013-04-26 A | 2013-07-25 A |  | 100% |  |  |  | start no earlier than 2013-04-26 |
| 87 | 10.3 | **Seals** |  | 76d | 2013-03-06 A | 2013-06-19 A |  | 100% |  |  |  |  |
| 88 | 10.3.1 | Code 1 definition and confirmation | milestone | 0w | 2013-03-06 A | 2013-03-06 A |  | 100% |  |  |  | start no earlier than 2013-02-28 |
| 89 | 10.3.2 | Code 1 delivery | milestone | 0w | 2013-06-19 A | 2013-06-19 A | 88 | 100% |  |  |  | finish no earlier than 2013-06-19 |
| 90 | 10.4 | **Vials** |  | 81d | 2013-02-25 A | 2013-06-17 A |  | 100% |  |  |  |  |
| 91 | 10.4.1 | Code 1 definition and confirmation |  | 1w | 2013-02-25 A | 2013-03-01 A |  | 100% |  |  |  | start no earlier than 2013-02-25 |
| 92 | 10.4.2 | Code 1 delivery |  | 15.2w | 2013-03-04 A | 2013-06-17 A |  | 100% |  |  |  | finish no earlier than 2013-06-17 |
| 93 | 11 | **Analytical Transfer** |  | 190d | 2013-03-20 A | 2013-12-05 | 14 | 33% | 128.25d | 323d |  |  |
| 94 | 11.1 | **GMP Analytical method transfer** |  | 190d | 2013-03-20 A | 2013-12-05 |  | 33% | 128.25d | 323d |  |  |
| 95 | 11.1.1 | Analytical transfer plan definition |  | 30d | 2013-03-20 A | 2013-04-30 A |  | 100% |  |  |  | finish no earlier than 2013-04-30 |
| 96 | 11.1.2 | Analytical transfer plan approval by Sending Unit |  | 3w | 2013-04-24 A | 2013-05-14 A |  | 100% |  |  |  | finish no earlier than 2013-05-14 |
| 97 | 11.1.3 | Standards & consumable list confirmation by Sending unit |  | 13d | 2013-06-05 A | 2013-06-21 A |  | 100% |  |  |  | finish no earlier than 2013-06-21 |
| 98 | 11.1.4 | Receiving Unit Equipment features confirmation by Sending Unit | milestone | 0w | 2013-06-21 A | 2013-06-21 A | 96 | 100% |  |  |  | finish no earlier than 2013-06-21 |
| 99 | 11.1.5 | Standards & consumable |  | 5.6w | 2013-06-24 A | 2013-07-31 A | 98 | 100% |  |  |  | finish no earlier than 2013-07-31 |
| 100 | 11.1.6 | Analytical transfer |  | 12w | 2013-08-01 | 2013-10-23 | 99 |  |  | 357d |  |  |

| ID | WBS | Task | Type | Duration | Start | Finish | Predecessors | Complete | Remaining | Total slack | Free slack | Constraint |
| --- | --- | --- | --- | --- | --- | --- | --- | --- | --- | --- | --- | --- |
| 101 | 11.1.7 | **Analytical transfer** |  | 49d | 2013-08-16 A | 2013-10-24 |  | 5% | 46.37d | 50d | 7d |  |
| 102 | 11.1.7.1 | **SEC (comparability)** |  | 23d | 2013-08-30 A | 2013-10-01 |  |  | 23d | 67d |  |  |
| 103 | 11.1.7.1.1 | Protocol approval | milestone | 0w | 2013-08-30 A | 2013-08-30 A |  | 100% |  |  |  | start no earlier than 2013-08-30 |
| 104 | 11.1.7.1.2 | Execution |  | 15d | 2013-09-02 | 2013-09-20 | 103 |  |  | 52d | 0d | start no earlier than 2013-09-02 |
| 105 | 11.1.7.1.3 | Report |  | 1w | 2013-09-23 | 2013-09-27 | 104 |  |  | 67d | 0d |  |
| 106 | 11.1.7.1.4 | Method issuing |  | 2d | 2013-09-30 | 2013-10-01 | 105 |  |  | 67d |  |  |
| 107 | 11.1.7.2 | **RP-HPLC (comparability)** |  | 37d | 2013-08-30 | 2013-10-22 |  |  |  | 52d |  |  |
| 108 | 11.1.7.2.1 | Protocol approval | milestone | 0w | 2013-08-30 | 2013-08-30 |  |  |  | 67d | 15d | finish no earlier than 2013-08-30 |
| 109 | 11.1.7.2.2 | Execution |  | 15d | 2013-09-23 | 2013-10-11 | 104, 108 |  |  | 52d | 0d |  |
| 110 | 11.1.7.2.3 | Report |  | 1w | 2013-10-14 | 2013-10-18 | 109 |  |  | 52d | 0d |  |
| 111 | 11.1.7.2.4 | Method issuing |  | 2d | 2013-10-21 | 2013-10-22 | 110 |  |  | 52d |  |  |
| 112 | 11.1.7.3 | **Verification Compendial Methods (subvisible; appearance solution; osmolality; pH; KF; recon)** |  | 25d | 2013-08-16 A | 2013-09-20 |  | 50% | 12.5d | 74d |  |  |
| 113 | 11.1.7.3.1 | Protocol approval | milestone | 0w | 2013-08-16 A | 2013-08-16 A |  | 100% |  |  |  | finish no earlier than 2013-08-16 |
| 114 | 11.1.7.3.2 | Execution |  | 1w | 2013-09-09 A | 2013-09-13 A | 113 | 100% |  |  |  | start no earlier than 2013-09-09 |
| 115 | 11.1.7.3.3 | Report |  | 1w | 2013-09-16 | 2013-09-20 | 114 |  |  | 74d |  |  |
| 116 | 11.1.7.4 | **Cleaning Method** |  | 39d | 2013-08-30 A | 2013-10-24 |  |  | 39d | 50d |  |  |
| 117 | 11.1.7.4.1 | ARL received - calculation confirmed |  | 3.2w | 2013-08-30 A | 2013-09-23 |  |  | 3.2w | 50d | 0d | finish no earlier than 2013-09-23 |
| 118 | 11.1.7.4.2 | protocol |  | 1w | 2013-09-24 | 2013-09-30 | 117 |  |  | 50d | 0d | finish no earlier than 2013-09-20 |
| 119 | 11.1.7.4.3 | execution |  | 2w | 2013-10-01 | 2013-10-14 | 118 |  |  | 50d | 0d | start no earlier than 2013-09-16 |
| 120 | 11.1.7.4.4 | report |  | 5d | 2013-10-15 | 2013-10-21 | 119 |  |  | 50d | 0d |  |
| 121 | 11.1.7.4.5 | Method issuing |  | 3d | 2013-10-22 | 2013-10-24 | 120 |  |  | 50d |  |  |
| 122 | 11.1.8 | **Analytical VALIDATION - Phase II** |  | 28d | 2013-11-01 | 2013-12-05 |  |  |  | 323d |  |  |
| 123 | 11.1.8.1 | **SEC (VALIDATION)** |  | 28d | 2013-11-01 | 2013-12-05 |  |  |  | 323d |  |  |
| 124 | 11.1.8.1.1 | Protocol approval | milestone | 0w | 2013-11-01 | 2013-11-01 |  |  |  | 330d | 7d | start no earlier than 2013-11-01 |
| 125 | 11.1.8.1.2 | Execution |  | 3w | 2013-11-11 | 2013-11-28 | 124, 156 |  |  | 323d | 0d |  |
| 126 | 11.1.8.1.3 | Report |  | 1w | 2013-11-29 | 2013-12-04 | 125 |  |  | 323d | 0d |  |
| 127 | 11.1.8.1.4 | Method issuing |  | 1d | 2013-12-05 | 2013-12-05 | 126 |  |  | 323d |  |  |

| ID | WBS | Task | Type | Duration | Start | Finish | Predecessors | Complete | Remaining | Total slack | Free slack | Constraint |
| --- | --- | --- | --- | --- | --- | --- | --- | --- | --- | --- | --- | --- |
| 128 | 11.1.8.2 | **RP-HPLC (VALIDATION)** |  | 27d | 2013-11-01 | 2013-12-04 |  |  |  | 324d |  |  |
| 129 | 11.1.8.2.1 | Protocol approval | milestone | 0w | 2013-11-01 | 2013-11-01 |  |  |  | 331d | 7d | start no earlier than 2013-11-01 |
| 130 | 11.1.8.2.2 | Execution |  | 3w | 2013-11-11 | 2013-11-28 | 129, 156 |  |  | 324d | 0d |  |
| 131 | 11.1.8.2.3 | Report |  | 1w | 2013-11-29 | 2013-12-04 | 130 |  |  | 324d |  |  |
| 132 | 12 | **Development activity - Non GMP** |  | 113d? | 2013-05-01 A | 2013-10-04 | 14 | 78% | 24.3d? | 64d | 21d |  |
| 133 | 12.1 | Development activity - Non GMP discussion and planning | milestone | 0w? | 2013-05-01 | 2013-05-01 |  |  |  | 0d |  | must start on 2013-05-01 |
| 134 | 12.2 | BDS availability: confirmed | milestone | 0w | 2013-05-15 A | 2013-05-15 A |  | 100% |  |  |  | finish no earlier than 2013-05-17 |
| 135 | 12.3 | Primary packaging materials availability: confirmed |  | 5d | 2013-05-28 A | 2013-06-03 A |  | 100% |  |  |  | start no earlier than 2013-06-04 |
| 136 | 12.4 | Activity plan (Cycle Confirmation 1 run): confirmed |  | 4w | 2013-05-01 A | 2013-05-28 A |  | 100% |  |  |  | finish no earlier than 2013-05-28 |
| 137 | 12.5 | Trial documentation preparation |  | 6.4w | 2013-05-28 A | 2013-07-10 A |  | 100% |  |  |  | finish no earlier than 2013-07-10 |
| 138 | 12.6 | Activity plan execution |  | 1w | 2013-07-22 A | 2013-07-26 A |  | 100% |  |  |  | start no earlier than 2013-07-08 |
| 139 | 12.7 | V max trial |  | 1d | 2013-07-23 A | 2013-07-23 A | 138SS | 100% |  |  |  |  |
| 140 | 12.8 | Non GMP product data analysis |  | 2w | 2013-07-24 A | 2013-08-06 A | 139 | 100% |  |  |  |  |
| 141 | 12.9 | Non GMP product data analysis |  | 4w | 2013-09-09 | 2013-10-04 | 138 |  |  | 64d |  | finish no earlier than 2013-10-04 |
| 142 | 13 | **Process Steility Assurance i.e. MF** |  | 83d | 2013-09-24 A | 2014-01-13 | 14 | 13% | 72.49d | 296d |  |  |
| 143 | 13.1 | MF Protocol approval (Receiving unit internal management) | milestone | 0w | 2013-10-04 A | 2013-10-04 A |  | 100% |  |  |  | finish no earlier than 2013-10-04 |
| 144 | 13.2 | MF MBR approval (Receiving Unit internal management) | milestone | 0w | 2013-10-04 A | 2013-10-04 A | 143 | 100% |  |  |  | start no earlier than 2013-10-01 |
| 145 | 13.3 | Primary packaging and excipients release for MF |  | 10d | 2013-09-24 A | 2013-10-07 A | 86, 92, 89, 79, 81, 83 | 100% |  |  |  | start no earlier than 2013-08-12 |
| 146 | 13.4 | Media Fill 1st run - manufacturing |  | 3d | 2013-10-08 | 2013-10-10 | 145 |  |  | 60d | 17d | start no earlier than 2013-10-08 |
| 147 | 13.5 | Media Fill 2nd run - manufacturing |  | 3d | 2013-11-13 | 2013-11-15 | 146 |  |  | 296d | 0d | start no earlier than 2013-11-13 |
| 148 | 13.6 | Media Fill 3rd run - manufacturing |  | 3d | 2013-11-17 | 2013-11-19 | 147 |  |  | 296d | 0d | start no earlier than 2013-11-17 |
| 149 | 13.7 | Media fill results |  | 15d | 2013-11-20 | 2013-12-09 | 148 |  |  | 296d | 0d |  |
| 150 | 13.8 | MF Report approved (to be shared with Sending Unit) |  | 5w | 2013-12-10 | 2014-01-13 | 149 |  |  | 296d |  |  |
| 151 | 13.9 | CCIT Micro |  | 4w | 2013-11-20 | 2013-12-16 | 148 |  |  | 316d |  |  |

| ID | WBS | Task | Type | Duration | Start | Finish | Predecessors | Total slack | Free slack | Constraint | Text1 |
| --- | --- | --- | --- | --- | --- | --- | --- | --- | --- | --- | --- |
| 152 | 14 | **Tech Runs** |  | 17.2w | 2013-09-24 | 2014-01-16 |  | 2d | 0d |  | Originally mentioned 5 weeks |
| 153 | 14.1 | raw materials avalability on site for Tech Run 1 - 2 - 3 (one single shipment) |  | 5d | 2013-10-14 | 2013-10-18 | 52SS, 51SS | 51d | 0d | start no earlier than 2013-10-14 |  |
| 154 | 14.2 | Raw materials for Tech Run 1 -2 -3 release |  | 3d | 2013-10-21 | 2013-10-23 | 153, 53 | 51d | 8d | finish no earlier than 2012-10-22 |  |
| 155 | 14.3 | Primary packaging and excipients release for Tech Runs 1 |  | 2w | 2013-09-24 | 2013-10-07 | 86, 92, 89, 79, 81, 83 | 63d | 0d | start no earlier than 2013-08-12 |  |
| 156 | 14.4 | Tech run Manufacturing 1 |  | 5d | 2013-11-04 | 2013-11-08 | 146, 132, 101, 77, 54, 24, 155, 154, 25, 45 | 43d | 0d | start no earlier than 2013-11-04 | Fill 3 weeks |
| 157 | 14.5 | Tech Runs 1 data evaluation |  | 3w | 2013-11-04 | 2013-11-21 | 156SS | 43d |  |  | 2 weeks after manufacturing comp |
| 158 | 14.6 | Primary packaging and excipients release for Tech Runs 2 | milestone | 0w | 2013-10-07 | 2013-10-07 | 155 | 78d |  |  |  |
| 159 | 14.7 | Tech run Manufacturing 2 |  | 5d | 2013-11-30 | 2013-12-05 | 46, 45 | 0d |  | start no earlier than 2013-11-30 |  |
| 160 | 14.8 | Primary packaging and excipients release for Tech Runs 3 | milestone | 0w | 2013-10-07 | 2013-10-07 | 155 | 63d | 44d |  |  |
| 161 | 14.9 | Tech run Manufacturing 3 |  | 7d | 2013-12-04 | 2013-12-12 | 160, 159SS+3d, 47 | 19d | 0d | start no earlier than 2013-12-04 |  |
| 162 | 14.10 | Tech Runs 2 and 3 data evaluation and discussion |  | 3w | 2013-12-04 | 2013-12-24 | 161SS | 19d |  | start no earlier than 2013-11-19 | 2 weeks after manufacturing comp |
| 163 | 14.11 | Tech runs report editing |  | 5w | 2013-12-06 | 2014-01-09 | 159 | 0d |  |  |  |
| 164 | 14.12 | Tech runs report approval |  | 1w | 2014-01-10 | 2014-01-16 | 163 | 2d | 0d |  |  |
| 165 | 14.13 | FMEA REVIEW |  | 1w | 2014-01-10 | 2014-01-16 | 164SS | 2d |  |  |  |
| 166 | 15 | **Process Validation & Stability** |  | 213d | 2014-02-18 | 2014-12-11 | 152FS+4w | 0d |  |  | Christmas week etc |
| 167 | 15.1 | **Process Validation Batches (3x - concentration 3)** |  | 171d | 2014-02-18 | 2014-10-14 |  | 0d |  |  |  |
| 168 | 15.1.1 | 3x concentration 3 Batches Manufacturing |  | 21d | 2014-02-18 | 2014-03-18 | 39 | 0d |  | start no earlier than 2014-02-18 |  |
| 169 | 15.1.2 | Batch Analysis |  | 4w | 2014-03-19 | 2014-04-15 | 168 | 230d |  |  |  |
| 170 | 15.1.3 | Stability 6 months |  | 26w | 2014-03-19 | 2014-09-16 | 168 | 0d |  |  |  |
| 171 | 15.1.4 | Stability Sample analyses and report issuing |  | 4w | 2014-09-17 | 2014-10-14 | 170 | 0d |  |  |  |
| 172 | 15.2 | **Process Validation Batches (3x - concentration 1)** |  | 106d | 2014-03-19 | 2014-08-13 | 168 | 37d |  |  |  |
| 173 | 15.2.1 | 3x concentration 1 Batches Manufacturing |  | 21d | 2014-03-19 | 2014-04-16 | 168 | 37d | 0d |  |  |
| 174 | 15.2.2 | Batch Analysis |  | 4w | 2014-04-17 | 2014-05-14 | 173 | 209d |  |  |  |
| 175 | 15.2.3 | Stability 3 months |  | 13w | 2014-04-17 | 2014-07-16 | 173 | 44d | 0d |  |  |
| 176 | 15.2.4 | Stability Sample analyses and report issuing |  | 4w | 2014-07-17 | 2014-08-13 | 175 | 44d |  |  |  |

Notes:
- 156: 5 day manufacturing, based on: / ·Day 1: compounding (6000 IU and Placebo). No HT for thawed DS at 2°-8°C. No HT for Buffers. / ·Day 1: DP bioburden reduction filtration. Overnight hold time after DP bioburden reduction filtration, before sterile filtration / ·Day 2: Sterile filtration and filling (6000 IU and Placebo). No HT for filling / ·Day 2: Start of freeze-drying / ·Day 3: Freeze-drying / ·Day 4: Freeze-drying / ·Day 5: end of Freeze-drying and Capping. No HT for crimping
- 159: 5 day manufacturing, based on: / ·Day 1: DP compounding. No HT for thawed DS at 2°-8°C. No HT for Buffers. / ·Day 1: DP bioburden reduction filtration. Overnight hold time after DP bioburden reduction filtration, before sterile filtration / ·Day 2: Sterile filtration and filling (12 hours). Start of freeze-drying / ·Day 3: Freeze-drying / ·Day 4: Freeze-drying / ·Day 5: end of Freeze-drying and Capping. No HT for crimping
- 161: 7 day manufacturing time per batch, based on: / ·Day 1: buffers preparation (overnight HT) and DS Thawing (overnight HT at 2°-8°C) / ·Day 2: compounding. and bioburden reduction filtration (overnight HT at 2°-8°C) / ·Day 3: sterile filtration and filling (12 hours). Start of freeze-drying / ·Day 4: freeze-drying / ·Day 5: freeze-drying / ·Day 6: end of freeze-drying / ·Day 7: capping (12 hours)
- 163: approx 1 month as a minimum Biogen Idec Request
- 168: 7 day manufacturing time per batch, based on: / ·Day 1: buffers preparation (overnight HT) and DS Thawing (overnight HT at 2°-8°C) / ·Day 2: compounding. and bioburden reduction filtration (overnight HT at 2°-8°C) / ·Day 3: sterile filtration and filling (12 hours). Start of freeze-drying / ·Day 4: freeze-drying / ·Day 5: freeze-drying / ·Day 6: end of freeze-drying / ·Day 7: capping (24 hours from end of freeze-drying to storage of capped vials in cold room)
- 173: 7 day manufacturing time per batch, based on: / ·Day 1: buffers preparation (overnight HT) and DS Thawing (overnight HT at 2°-8°C) / ·Day 2: compounding. and bioburden reduction filtration (overnight HT at 2°-8°C) / ·Day 3: sterile filtration and filling (12 hours). Start of freeze-drying / ·Day 4: freeze-drying / ·Day 5: freeze-drying / ·Day 6: end of freeze-drying / ·Day 7: capping (24 hours from end of freeze-drying to storage of capped vials in cold room)

| ID | WBS | Task | Type | Duration | Start | Finish | Predecessors | Total slack | Free slack |
| --- | --- | --- | --- | --- | --- | --- | --- | --- | --- |
| 177 | 15.3 | **Process Validation Batches (1x -concentration 2)** |  | 92d | 2014-04-17 | 2014-08-22 |  | 37d |  |
| 178 | 15.3.1 | 1x concentration 2 Batch Manufacturing |  | 7d | 2014-04-17 | 2014-04-25 | 173 | 37d | 0d |
| 179 | 15.3.2 | Batch Analysis |  | 4w | 2014-04-28 | 2014-05-23 | 178 | 202d |  |
| 180 | 15.3.3 | Stability 3 months |  | 13w | 2014-04-28 | 2014-07-25 | 178 | 37d | 0d |
| 181 | 15.3.4 | Stability Sample analyses and report issuing |  | 4w | 2014-07-28 | 2014-08-22 | 180 | 37d |  |
| 182 | 15.4 | **Process Validation Batches (1x -concentration 4)** |  | 137d | 2014-04-28 | 2014-11-04 |  | 58d |  |
| 183 | 15.4.1 | 1x concentration 4 Batches Manufacturing |  | 7d | 2014-04-28 | 2014-05-06 | 178, 42 | 58d | 0d |
| 184 | 15.4.2 | Batches Analysis |  | 4w | 2014-05-07 | 2014-06-03 | 183 | 195d |  |
| 185 | 15.4.3 | Stability Sample analyses and report issuing |  | 26w | 2014-05-07 | 2014-11-04 | 183 | 85d |  |
| 186 | 15.5 | **Process Validation Batches (1x -concentration 5)** |  | 157d | 2014-05-07 | 2014-12-11 |  | 58d |  |
| 187 | 15.5.1 | 1x concentration 5 Batches Manufacturing |  | 7d | 2014-05-07 | 2014-05-15 | 183, 43 | 58d | 0d |
| 188 | 15.5.2 | Batches Analysis |  | 4w | 2014-05-16 | 2014-06-12 | 187 | 58d | 0d |
| 189 | 15.5.3 | Stability Sample analyses and report issuing |  | 26w | 2014-06-13 | 2014-12-11 | 188 | 58d |  |
| 190 | 15.6 | **PVR data analysis and report wrap-up** |  | 45d | 2014-05-16 | 2014-07-17 |  | 63d |  |
| 191 | 15.6.1 | Batch record review |  | 5w | 2014-05-16 | 2014-06-19 | 187 | 63d | 0d |
| 192 | 15.6.2 | PVR completion |  | 4w | 2014-06-20 | 2014-07-17 | 191 | 63d | 0d |
| 193 | 15.7 | FMEA REVIEW |  | 1w | 2014-07-18 | 2014-07-24 | 192 | 138d | 0d |
| 194 | 15.8 | **TT Report** |  | 20d | 2014-07-25 | 2014-08-21 |  | 138d |  |
| 195 | 15.8.1 | TT report draft sharing |  | 2w | 2014-07-25 | 2014-08-07 | 193 | 138d | 0d |
| 196 | 15.8.2 | TT report updating and Approval |  | 2w | 2014-08-08 | 2014-08-21 | 195 | 138d |  |
| 197 | 16 | **Secondary Packaging activities** |  | 4d? | 2014-01-17 | 2014-01-22 | 76 | 289d |  |
| 198 | 16.1 | Definition of the II PCK design |  | 0.2w? | 2014-01-17 | 2014-01-17 | 152 | 289d | 0d |
| 199 | 16.2 | Implementation in receiving unit |  | 0.2w? | 2014-01-20 | 2014-01-20 | 198 | 289d | 0d |
| 200 | 16.3 | Orders of materials |  | 0.2w? | 2014-01-21 | 2014-01-21 | 199 | 289d | 0d |
| 201 | 16.4 | Validation of II Pck |  | 0.2w? | 2014-01-22 | 2014-01-22 | 200 | 289d |  |
| 202 | 17 | Stability data processing and Filing finalization |  | 2w | 2014-10-15 | 2014-10-28 | 181, 171, 176, 192 | 0d |  |
| 203 | 18 | Receiving Unit process/site information ready for Sumbission | milestone | 0d | 2014-10-28 | 2014-10-28 | 202 | 0d |  |
| 204 | 19 | Regulatory Agency review |  | 18w | 2014-10-29 | 2015-03-03 | 203 | 0d |  |
| 205 | 20 | SU Approval from authorities | milestone | 0d | 2015-03-03 | 2015-03-03 | 204 | 0d |  |
| 206 | 21 | Launch on the market | milestone | 0d | 2015-03-03 | 2015-03-03 | 205 | 0d |  |

Notes:
- 178: 7 day manufacturing time per batch, based on: / ·Day 1: buffers preparation (overnight HT) and DS Thawing (overnight HT at 2°-8°C) / ·Day 2: compounding. and bioburden reduction filtration (overnight HT at 2°-8°C) / ·Day 3: sterile filtration and filling (12 hours). Start of freeze-drying / ·Day 4: freeze-drying / ·Day 5: freeze-drying / ·Day 6: end of freeze-drying / ·Day 7: capping (24 hours from end of freeze-drying to storage of capped vials in cold room)
- 183: 7 day manufacturing time per batch, based on: / ·Day 1: buffers preparation (overnight HT) and DS Thawing (overnight HT at 2°-8°C) / ·Day 2: compounding. and bioburden reduction filtration (overnight HT at 2°-8°C) / ·Day 3: sterile filtration and filling (12 hours). Start of freeze-drying / ·Day 4: freeze-drying / ·Day 5: freeze-drying / ·Day 6: end of freeze-drying / ·Day 7: capping (24 hours from end of freeze-drying to storage of capped vials in cold room)
- 185: Stability 6 months
- 187: 7 day manufacturing time per batch, based on: / ·Day 1: buffers preparation (overnight HT) and DS Thawing (overnight HT at 2°-8°C) / ·Day 2: compounding. and bioburden reduction filtration (overnight HT at 2°-8°C) / ·Day 3: sterile filtration and filling (12 hours). Start of freeze-drying / ·Day 4: freeze-drying / ·Day 5: freeze-drying / ·Day 6: end of freeze-drying / ·Day 7: capping (24 hours from end of freeze-drying to storage of capped vials in cold room)
- 189: Stability 6 months
- 190: Text1: Inlcuded
- 191: Text1: Inlcuded
- 192: Text1: Inlcuded
- 202: Text1: Included to link to 69
- 203: Text1: Updated title as this does not include BIIB process for BLA authoring etc.
